# Sample Project Plan

Schedule from MS Project, 2009-04-01 to 2009-05-15, status date 2009-04-01, costs in $.

## Calendars

- Standard: Mon-Fri 08:00-12:00, 13:00-17:00; Sat-Sun off.

## Resources

| Resource | Rate | Cost per use |
| --- | --- | --- |
| Karl Knapp | 100 | 1000 |
| Roger Smith | 50 |  |

## Schedule

| ID | WBS | Task | Type | Duration | Start | Finish | Predecessors | Baseline start | Baseline finish | Baseline duration | Total slack | Resources | Work | Cost | Baseline cost |
| --- | --- | --- | --- | --- | --- | --- | --- | --- | --- | --- | --- | --- | --- | --- | --- |
| 1 | 1 | **Project Name** |  | 32.08d? | 2009-04-01 | 2009-05-15 |  | 2009-04-01 | 2009-05-15 | 32.08d? | 0d |  | 469h | 59,633.33 | 59,633.33 |
| 2 | 1.1 | **Intiiation** |  | 2.62d? | 2009-04-01 | 2009-04-03 |  | 2009-04-01 | 2009-04-03 | 2.62d? | 0d |  | 24.67h | 7,283.33 | 7,283.33 |
| 3 | 1.1.1 | **Project Initiation Form** |  | 2.17d? | 2009-04-01 | 2009-04-03 |  | 2009-04-01 | 2009-04-03 | 2.17d? | 0d |  | 17.33h | 5,733.33 | 5,733.33 |
| 4 | 1.1.1.1 | Stakeholder Analysis |  | 0.54d? | 2009-04-01 | 2009-04-01 |  | 2009-04-01 | 2009-04-01 | 0.54d? | 0d | Karl Knapp | 4.33h | 1,433.33 | 1,433.33 |
| 5 | 1.1.1.2 | Scope Definition |  | 0.88d? | 2009-04-01 | 2009-04-02 | 4 | 2009-04-01 | 2009-04-02 | 0.88d? | 0d | Karl Knapp | 7h | 1,700 | 1,700 |
| 6 | 1.1.1.3 | Cost/Benefit Analysis |  | 0.5d? | 2009-04-02 | 2009-04-02 | 5 | 2009-04-02 | 2009-04-02 | 0.5d? | 0d | Karl Knapp | 4h | 1,400 | 1,400 |
| 7 | 1.1.1.4 | Create Initiation Form |  | 0.25d? | 2009-04-02 | 2009-04-03 | 6 | 2009-04-02 | 2009-04-03 | 0.25d? | 0d | Karl Knapp | 2h | 1,200 | 1,200 |
| 8 | 1.1.2 | Project Initiation Meeting |  | 0.46d? | 2009-04-03 | 2009-04-03 | 7 | 2009-04-03 | 2009-04-03 | 0.46d? | 0d | Karl Knapp; Roger Smith | 7.33h | 1,550 | 1,550 |
| 9 | 1.1.3 | Project Initiation Stage Gate | milestone | 0d | 2009-04-03 | 2009-04-03 | 8 | 2009-04-03 | 2009-04-03 | 0d | 0d |  |  |  |  |
| 10 | 1.2 | **Planning** |  | 9.54d? | 2009-04-03 | 2009-04-17 | 2 | 2009-04-03 | 2009-04-17 | 9.54d? | 0d |  | 162.33h | 23,616.67 | 23,616.67 |
| 11 | 1.2.1 | Identify & Involve Planning Team |  | 2.08d? | 2009-04-03 | 2009-04-07 |  | 2009-04-03 | 2009-04-07 | 2.08d? | 0d | Karl Knapp | 16.67h | 2,666.67 | 2,666.67 |
| 12 | 1.2.2 | Activity Identification |  | 1.08d? | 2009-04-07 | 2009-04-08 | 11 | 2009-04-07 | 2009-04-08 | 1.08d? | 0d | Karl Knapp; Roger Smith | 17.33h | 2,300 | 2,300 |
| 13 | 1.2.3 | Activity Estimation |  | 1.08d? | 2009-04-08 | 2009-04-09 | 12 | 2009-04-08 | 2009-04-09 | 1.08d? | 0d | Roger Smith | 8.67h | 433.33 | 433.33 |
| 14 | 1.2.4 | Precedence Relationship Development |  | 0.54d? | 2009-04-09 | 2009-04-10 | 13 | 2009-04-09 | 2009-04-10 | 0.54d? | 0d | Roger Smith | 4.33h | 216.67 | 216.67 |
| 15 | 1.2.5 | Resource Assignment |  | 1.04d? | 2009-04-10 | 2009-04-13 | 14 | 2009-04-10 | 2009-04-13 | 1.04d? | 0d | Karl Knapp | 8.33h | 1,833.33 | 1,833.33 |
| 16 | 1.2.6 | Create Schedule Management Plan |  | 0.54d? | 2009-04-13 | 2009-04-13 | 15 | 2009-04-13 | 2009-04-13 | 0.54d? | 0d | Karl Knapp | 4.33h | 1,433.33 | 1,433.33 |
| 17 | 1.2.7 | Create Budget |  | 1.08d? | 2009-04-14 | 2009-04-15 | 16 | 2009-04-14 | 2009-04-15 | 1.08d? | 2.08d | Karl Knapp | 8.67h | 1,866.67 | 1,866.67 |
| 18 | 1.2.8 | Create Risk Management Plan |  | 1.08d? | 2009-04-14 | 2009-04-15 | 16 | 2009-04-14 | 2009-04-15 | 1.08d? | 2.08d | Karl Knapp | 8.67h | 1,866.67 | 1,866.67 |
| 19 | 1.2.9 | Create Scope Management Plan |  | 0.54d? | 2009-04-14 | 2009-04-14 | 16 | 2009-04-14 | 2009-04-14 | 0.54d? | 2.62d | Karl Knapp | 4.33h | 1,433.33 | 1,433.33 |
| 20 | 1.2.10 | Create Human Resources Management Plan |  | 0.54d? | 2009-04-14 | 2009-04-14 | 16 | 2009-04-14 | 2009-04-14 | 0.54d? | 2.62d | Karl Knapp | 4.33h | 1,433.33 | 1,433.33 |
| 21 | 1.2.11 | Create Quality Management Plan |  | 1.08d? | 2009-04-14 | 2009-04-15 | 16 | 2009-04-14 | 2009-04-15 | 1.08d? | 2.08d | Karl Knapp | 8.67h | 1,866.67 | 1,866.67 |
| 22 | 1.2.12 | Create Contract Management Plan |  | 1.08d? | 2009-04-14 | 2009-04-15 | 16 | 2009-04-14 | 2009-04-15 | 1.08d? | 2.08d | Karl Knapp | 8.67h | 1,866.67 | 1,866.67 |
| 23 | 1.2.13 | Create Communications Management Plan |  | 1.08d? | 2009-04-14 | 2009-04-15 | 16 | 2009-04-14 | 2009-04-15 | 1.08d? | 2.08d | Karl Knapp | 8.67h | 1,866.67 | 1,866.67 |
| 24 | 1.2.14 | Create Project Test Plan |  | 3.17d? | 2009-04-14 | 2009-04-17 | 16 | 2009-04-14 | 2009-04-17 | 3.17d? | 0d | Roger Smith | 25.33h | 1,266.67 | 1,266.67 |
| 25 | 1.2.15 | Create Project Implementation Plan |  | 3.17d? | 2009-04-14 | 2009-04-17 | 16 | 2009-04-14 | 2009-04-17 | 3.17d? | 0d | Roger Smith | 25.33h | 1,266.67 | 1,266.67 |
| 26 | 1.2.16 | Project Plan Stage Gate | milestone | 0d | 2009-04-17 | 2009-04-17 | 17, 18, 19, 20, 21, 22, 25, 24 | 2009-04-17 | 2009-04-17 | 0d | 0d |  |  |  |  |

| ID | WBS | Task | Type | Duration | Start | Finish | Predecessors | Baseline start | Baseline finish | Baseline duration | Total slack | Resources | Work | Cost | Baseline cost |
| --- | --- | --- | --- | --- | --- | --- | --- | --- | --- | --- | --- | --- | --- | --- | --- |
| 27 | 1.3 | **Development** |  | 10d? | 2009-04-17 | 2009-05-01 | 10 | 2009-04-17 | 2009-05-01 | 10d? | 0d |  | 160h | 13,000 | 13,000 |
| 28 | 1.3.1 | Project Execution |  | 10d? | 2009-04-17 | 2009-05-01 |  | 2009-04-17 | 2009-05-01 | 10d? | 0d | Roger Smith | 80h | 4,000 | 4,000 |
| 29 | 1.3.2 | Project Control |  | 10d? | 2009-04-17 | 2009-05-01 |  | 2009-04-17 | 2009-05-01 | 10d? | 0d | Karl Knapp | 80h | 9,000 | 9,000 |
| 30 | 1.3.3 | Project Development Stage Gate | milestone | 0d | 2009-05-01 | 2009-05-01 | 28, 29 | 2009-05-01 | 2009-05-01 | 0d | 0d |  |  |  |  |
| 31 | 1.4 | **Testing** |  | 4.33d? | 2009-05-01 | 2009-05-07 | 27 | 2009-05-01 | 2009-05-07 | 4.33d? | 0d |  | 52h | 4,466.67 | 4,466.67 |
| 32 | 1.4.1 | Perform Project Deliverables Testing |  | 2.17d? | 2009-05-01 | 2009-05-05 |  | 2009-05-01 | 2009-05-05 | 2.17d? | 0d | Roger Smith; Karl Knapp | 34.67h | 3,600 | 3,600 |
| 33 | 1.4.2 | Make Corrective Actions |  | 2.17d? | 2009-05-05 | 2009-05-07 | 32 | 2009-05-05 | 2009-05-07 | 2.17d? | 0d | Roger Smith | 17.33h | 866.67 | 866.67 |
| 34 | 1.4.3 | Testing Sign Off Stage Gate | milestone | 0d | 2009-05-07 | 2009-05-07 | 33 | 2009-05-07 | 2009-05-07 | 0d | 0d |  |  |  |  |
| 35 | 1.5 | **Implementation** |  | 3.25d? | 2009-05-07 | 2009-05-12 | 31 | 2009-05-07 | 2009-05-12 | 3.25d? | 0d |  | 34.67h | 3,166.67 | 3,166.67 |
| 36 | 1.5.1 | Perform Training |  | 2.17d? | 2009-05-07 | 2009-05-11 |  | 2009-05-07 | 2009-05-11 | 2.17d? | 0d | Roger Smith | 17.33h | 866.67 | 866.67 |
| 37 | 1.5.2 | Implement Project |  | 1.08d? | 2009-05-11 | 2009-05-12 | 36 | 2009-05-11 | 2009-05-12 | 1.08d? | 0d | Roger Smith; Karl Knapp | 17.33h | 2,300 | 2,300 |
| 38 | 1.5.3 | Implementation Stage Gate | milestone | 0d | 2009-05-12 | 2009-05-12 | 37 | 2009-05-12 | 2009-05-12 | 0d | 0d |  |  |  |  |
| 39 | 1.6 | **Closure** |  | 2.33d? | 2009-05-12 | 2009-05-15 | 35 | 2009-05-12 | 2009-05-15 | 2.33d? | 0d |  | 35.33h | 8,100 | 8,100 |
| 40 | 1.6.1 | Celebrate |  | 0.54d? | 2009-05-12 | 2009-05-13 |  | 2009-05-12 | 2009-05-13 | 0.54d? | 0d | Karl Knapp; Roger Smith | 8.67h | 1,650 | 1,650 |
| 41 | 1.6.2 | Lessons Learned |  | 0.54d? | 2009-05-13 | 2009-05-13 | 40 | 2009-05-13 | 2009-05-13 | 0.54d? | 0d | Roger Smith; Karl Knapp | 8.67h | 1,650 | 1,650 |
| 42 | 1.6.3 | Release Resources |  | 0.25d? | 2009-05-13 | 2009-05-14 | 41 | 2009-05-13 | 2009-05-14 | 0.25d? | 0d | Karl Knapp | 2h | 1,200 | 1,200 |
| 43 | 1.6.4 | Administrative Closure |  | 1d? | 2009-05-14 | 2009-05-15 | 42 | 2009-05-14 | 2009-05-15 | 1d? | 0d | Karl Knapp | 8h | 1,800 | 1,800 |
| 44 | 1.6.5 | Contract Closure |  | 1d? | 2009-05-14 | 2009-05-15 | 42 | 2009-05-14 | 2009-05-15 | 1d? | 0d | Karl Knapp | 8h | 1,800 | 1,800 |
